# VOORBEREIDING AFBOUW FASE

Schedule from MS Project, 2003-01-12 to 2003-05-18, status date 2003-01-08.
BAM Nelissen Van Egteren

## Calendars

- ALLEEN WERKDAGEN: Mon-Fri 08:30-12:30, 13:00-17:00; Sat-Sun off. Exceptions (off unless hours are given): 2003-01-11 to 2003-01-12 08:30-12:30, 13:00-17:00, 2003-01-18 to 2003-01-19 08:30-12:30, 13:00-17:00, 2003-01-25 to 2003-01-26 08:30-12:30, 13:00-17:00, 2003-02-01 to 2003-02-02 08:30-12:30, 13:00-17:00, 2003-02-08 to 2003-02-09 08:30-12:30, 13:00-17:00, 2003-02-15 to 2003-02-16 08:30-12:30, 13:00-17:00, 2003-02-22 to 2003-02-23 08:30-12:30, 13:00-17:00, 2003-03-01 to 2003-03-02 08:30-12:30, 13:00-17:00, 2003-03-08 to 2003-03-09 08:30-12:30, 13:00-17:00, 2003-03-15 to 2003-03-16 08:30-12:30, 13:00-17:00, 2003-03-22 to 2003-03-23 08:30-12:30, 13:00-17:00, 2003-03-29 to 2003-03-30 08:30-12:30, 13:00-17:00, 2003-04-05 to 2003-04-06 08:30-12:30, 13:00-17:00, 2003-04-12 to 2003-04-13 08:30-12:30, 13:00-17:00, 2003-04-19 to 2003-04-20 08:30-12:30, 13:00-17:00, 2003-04-26 to 2003-04-27 08:30-12:30, 13:00-17:00, 2003-05-03 to 2003-05-04 08:30-12:30, 13:00-17:00, 2003-05-10 to 2003-05-11 08:30-12:30, 13:00-17:00, 2003-05-17 to 2003-05-18 08:30-12:30, 13:00-17:00.

## Schedule

| ID | WBS | Task | Type | Duration | Start | Finish | Predecessors | Total slack | Free slack |
| --- | --- | --- | --- | --- | --- | --- | --- | --- | --- |
| 1 | 1 | **BINNENKOZIJNEN+PUIEN** |  | 127d | 2003-01-12 | 2003-05-18 |  | 0d |  |
| 2 | 1.1 | bestektekeningen |  | 3d | 2003-01-12 | 2003-01-14 |  | 0d |  |
| 3 | 1.2 | overzichtstekening kozijnen |  | 5d | 2003-01-15 | 2003-01-19 | 2 | 0d |  |
| 4 | 1.3 | principe details kozijnen |  | 5d | 2003-01-15 | 2003-01-19 | 3SS | 0d |  |
| 5 | 1.4 | **contractvorming** |  | 36d | 2003-01-20 | 2003-02-24 | 4 | 0d |  |
| 6 | 1.4.1 | prijsaanvraag opstellen |  | 5d | 2003-01-20 | 2003-01-24 |  | 0d |  |
| 7 | 1.4.2 | offerte aanvraag leveranciers |  | 5d | 2003-01-25 | 2003-01-29 | 6 | 0d |  |
| 8 | 1.4.3 | opstellen offerte door leveranciers |  | 10d | 2003-01-30 | 2003-02-08 | 7 | 0d |  |
| 9 | 1.4.4 | offertes leveranciers beoordelen |  | 5d | 2003-02-09 | 2003-02-13 | 8 | 0d |  |
| 10 | 1.4.5 | prijsonderhandeling met lev. |  | 5d | 2003-02-14 | 2003-02-18 | 9 | 0d |  |
| 11 | 1.4.6 | leveringscontract opstellen |  | 3d | 2003-02-19 | 2003-02-21 | 10 | 0d |  |
| 12 | 1.4.7 | leveringscontract tekenen |  | 3d | 2003-02-22 | 2003-02-24 | 11 | 0d |  |
| 13 | 1.5 | **productietekening kozijnen** |  | 33d | 2003-02-25 | 2003-03-29 |  | 0d |  |
| 14 | 1.5.1 | concept productietek.maken |  | 10d | 2003-02-25 | 2003-03-06 | 12 | 0d |  |
| 15 | 1.5.2 | controle tekening door partners |  | 10d | 2003-03-07 | 2003-03-16 | 14 | 0d |  |
| 16 | 1.5.3 | commentaar partners verwerken |  | 5d | 2003-03-17 | 2003-03-21 | 15 | 0d |  |
| 17 | 1.5.4 | productie.tek.definitief maken |  | 5d | 2003-03-22 | 2003-03-26 | 16 | 0d |  |
| 18 | 1.5.5 | productietekening goedkeuren |  | 3d | 2003-03-27 | 2003-03-29 | 17 | 0d |  |
| 19 | 1.6 | **productieproces kozijnen** |  | 50d | 2003-03-30 | 2003-05-18 | 18 | 0d |  |
| 20 | 1.6.1 | voorbereiding productie |  | 10d | 2003-03-30 | 2003-04-08 |  | 0d |  |
| 21 | 1.6.2 | produceren kozijnen |  | 40d | 2003-04-09 | 2003-05-18 | 20 | 0d |  |
| 22 | 1.6.3 | afroepen 1e levering kozijnen |  | 1d | 2003-04-29 | 2003-04-29 | 21SS+20d | 10d | 0d |
| 23 | 1.6.4 | start montage kozijnen | milestone | 0d | 2003-05-08 | 2003-05-08 | 22SS+10d | 10d |  |
| 25 | 2 | **SYSTEEM WANDEN** |  | 120d | 2003-01-12 | 2003-05-11 |  | 7d |  |
| 26 | 2.1 | bestektekeningen |  | 3d | 2003-01-12 | 2003-01-14 |  | 7d | 0d |
| 27 | 2.2 | overzichtstekening systeemwanden |  | 5d | 2003-01-15 | 2003-01-19 | 26 | 7d | 0d |
| 28 | 2.3 | principe details systeemwanden |  | 5d | 2003-01-15 | 2003-01-19 | 27SS | 7d | 0d |

| ID | WBS | Task | Type | Duration | Start | Finish | Predecessors | Total slack | Free slack |
| --- | --- | --- | --- | --- | --- | --- | --- | --- | --- |
| 29 | 2.4 | **contractvorming** |  | 29d | 2003-01-20 | 2003-02-17 | 28 | 7d |  |
| 30 | 2.4.1 | prijsaanvraag opstellen |  | 3d | 2003-01-20 | 2003-01-22 |  | 7d | 0d |
| 31 | 2.4.2 | offerte aanvraag leveranciers |  | 3d | 2003-01-23 | 2003-01-25 | 30 | 7d | 0d |
| 32 | 2.4.3 | opstellen offerte door leveranciers |  | 10d | 2003-01-26 | 2003-02-04 | 31 | 7d | 0d |
| 33 | 2.4.4 | offertes leveranciers beoordelen |  | 3d | 2003-02-05 | 2003-02-07 | 32 | 7d | 0d |
| 34 | 2.4.5 | prijsonderhandeling met lev. |  | 5d | 2003-02-08 | 2003-02-12 | 33 | 7d | 0d |
| 35 | 2.4.6 | leveringscontract opstellen |  | 3d | 2003-02-13 | 2003-02-15 | 34 | 7d | 0d |
| 36 | 2.4.7 | leveringscontract tekenen |  | 2d | 2003-02-16 | 2003-02-17 | 35 | 7d | 0d |
| 37 | 2.5 | **productietekening systeemwanden** |  | 33d | 2003-02-18 | 2003-03-22 |  | 7d |  |
| 38 | 2.5.1 | concept productietek.maken |  | 10d | 2003-02-18 | 2003-02-27 | 36 | 7d | 0d |
| 39 | 2.5.2 | controle tekening door partners |  | 10d | 2003-02-28 | 2003-03-09 | 38 | 7d | 0d |
| 40 | 2.5.3 | commentaar partners verwerken |  | 5d | 2003-03-10 | 2003-03-14 | 39 | 7d | 0d |
| 41 | 2.5.4 | productie.tek.definitief maken |  | 5d | 2003-03-15 | 2003-03-19 | 40 | 7d | 0d |
| 42 | 2.5.5 | productietekening goedkeuren |  | 3d | 2003-03-20 | 2003-03-22 | 41 | 7d | 0d |
| 43 | 2.6 | **productieproces systeemwanden** |  | 50d | 2003-03-23 | 2003-05-11 | 42 | 7d |  |
| 44 | 2.6.1 | voorbereiding productie |  | 10d | 2003-03-23 | 2003-04-01 |  | 7d | 0d |
| 45 | 2.6.2 | produceren systeemwanden |  | 40d | 2003-04-02 | 2003-05-11 | 44 | 7d | 0d |
| 46 | 2.6.3 | afroepen 1e levering wanden |  | 1d | 2003-04-22 | 2003-04-22 | 45SS+20d | 17d | 0d |
| 47 | 2.6.4 | start montage systeemwanden | milestone | 0d | 2003-05-01 | 2003-05-01 | 46SS+10d | 17d |  |
| 49 | 3 | **SYSTEEM PLAFONDS** |  | 97d | 2003-01-12 | 2003-04-18 |  | 30d |  |
| 50 | 3.1 | bestektekeningen |  | 3d | 2003-01-12 | 2003-01-14 |  | 30d | 0d |
| 51 | 3.2 | overzichtstekening systeemplafonds |  | 5d | 2003-01-15 | 2003-01-19 | 50 | 30d | 0d |
| 52 | 3.3 | principe details systeemplafonds |  | 5d | 2003-01-15 | 2003-01-19 | 51SS | 30d | 0d |
| 53 | 3.4 | **contractvorming** |  | 28d | 2003-01-20 | 2003-02-16 | 52 | 30d |  |
| 54 | 3.4.1 | prijsaanvraag opstellen |  | 3d | 2003-01-20 | 2003-01-22 |  | 30d | 0d |
| 55 | 3.4.2 | offerte aanvraag leveranciers |  | 3d | 2003-01-23 | 2003-01-25 | 54 | 30d | 0d |
| 56 | 3.4.3 | opstellen offerte door leveranciers |  | 10d | 2003-01-26 | 2003-02-04 | 55 | 30d | 0d |
| 57 | 3.4.4 | offertes leveranciers beoordelen |  | 3d | 2003-02-05 | 2003-02-07 | 56 | 30d | 0d |
| 58 | 3.4.5 | prijsonderhandeling met lev. |  | 5d | 2003-02-08 | 2003-02-12 | 57 | 30d | 0d |
| 59 | 3.4.6 | leveringscontract opstellen |  | 2d | 2003-02-13 | 2003-02-14 | 58 | 30d | 0d |
| 60 | 3.4.7 | leveringscontract tekenen |  | 2d | 2003-02-15 | 2003-02-16 | 59 | 30d | 0d |

| ID | WBS | Task | Type | Duration | Start | Finish | Predecessors | Total slack | Free slack |
| --- | --- | --- | --- | --- | --- | --- | --- | --- | --- |
| 61 | 3.5 | **productietekening plafonds** |  | 26d | 2003-02-17 | 2003-03-14 |  | 30d |  |
| 62 | 3.5.1 | concept productietek.maken |  | 10d | 2003-02-17 | 2003-02-26 | 60 | 30d | 0d |
| 63 | 3.5.2 | controle tekening door partners |  | 5d | 2003-02-27 | 2003-03-03 | 62 | 30d | 0d |
| 64 | 3.5.3 | commentaar partners verwerken |  | 3d | 2003-03-04 | 2003-03-06 | 63 | 30d | 0d |
| 65 | 3.5.4 | productie.tek.definitief maken |  | 5d | 2003-03-07 | 2003-03-11 | 64 | 30d | 0d |
| 66 | 3.5.5 | productietekening goedkeuren |  | 3d | 2003-03-12 | 2003-03-14 | 65 | 30d | 0d |
| 67 | 3.6 | **productieproces plafonds** |  | 35d | 2003-03-15 | 2003-04-18 | 66 | 30d |  |
| 68 | 3.6.1 | voorbereiding productie |  | 5d | 2003-03-15 | 2003-03-19 |  | 30d | 0d |
| 69 | 3.6.2 | produceren systeemplafonds |  | 30d | 2003-03-20 | 2003-04-18 | 68 | 30d | 0d |
| 70 | 3.6.3 | afroepen 1e levering plafonds |  | 1d | 2003-04-04 | 2003-04-04 | 69SS+15d | 35d | 0d |
| 71 | 3.6.4 | start montage systeemplafonds | milestone | 0d | 2003-04-13 | 2003-04-13 | 70SS+10d | 35d |  |
| 73 | 4 | **TEGELWERK LEV+VERWERKEN** |  | 53d | 2003-01-12 | 2003-03-05 |  | 74d |  |
| 74 | 4.1 | bestektekeningen |  | 3d | 2003-01-12 | 2003-01-14 |  | 74d | 0d |
| 75 | 4.2 | overzichtstekening tegelwerk |  | 5d | 2003-01-15 | 2003-01-19 | 74 | 119d | 0d |
| 76 | 4.3 | principe details tegelwerk |  | 5d | 2003-01-15 | 2003-01-19 | 75SS | 119d |  |
| 77 | 4.4 | bemonstering wand+vloertegels |  | 5d | 2003-01-17 | 2003-01-21 | 74SS+5d | 74d | 0d |
| 78 | 4.5 | **contractvorming** |  | 23d | 2003-01-22 | 2003-02-13 | 77 | 74d |  |
| 79 | 4.5.1 | prijsaanvraag opstellen |  | 2d | 2003-01-22 | 2003-01-23 |  | 74d | 0d |
| 80 | 4.5.2 | offerte aanvraag leveranciers |  | 2d | 2003-01-24 | 2003-01-25 | 79 | 74d | 0d |
| 81 | 4.5.3 | opstellen offerte door leveranciers |  | 10d | 2003-01-26 | 2003-02-04 | 80 | 74d | 0d |
| 82 | 4.5.4 | offertes leveranciers beoordelen |  | 2d | 2003-02-05 | 2003-02-06 | 81 | 74d | 0d |
| 83 | 4.5.5 | prijsonderhandeling met lev. |  | 4d | 2003-02-07 | 2003-02-10 | 82 | 74d | 0d |
| 84 | 4.5.6 | leveringscontract opstellen |  | 2d | 2003-02-11 | 2003-02-12 | 83 | 74d | 0d |
| 85 | 4.5.7 | leveringscontract tekenen |  | 1d | 2003-02-13 | 2003-02-13 | 84 | 74d | 0d |

| ID | WBS | Task | Type | Duration | Start | Finish | Predecessors | Total slack | Free slack |
| --- | --- | --- | --- | --- | --- | --- | --- | --- | --- |
| 86 | 4.6 | **voorbereiden tegelwerk** |  | 20d | 2003-02-14 | 2003-03-05 |  | 74d |  |
| 87 | 4.6.1 | bestellen wand+vloertegels |  | 5d | 2003-02-14 | 2003-02-18 | 85 | 74d | 0d |
| 88 | 4.6.2 | levertijd wand + vloertegels |  | 10d | 2003-02-19 | 2003-02-28 | 87 | 74d | 0d |
| 89 | 4.6.3 | werkvoorbereiding tegelzetter |  | 10d | 2003-02-24 | 2003-03-05 | 88SS+5d | 74d | 0d |
| 90 | 4.6.4 | start tegelwerk | milestone | 0d | 2003-03-05 | 2003-03-05 | 89 | 74d |  |
